# Proyecto de Reforestación

Schedule from Primavera P6, 2024-08-08 to 2026-01-12, data date 2024-08-08, costs in PEN.

## Calendars

- Corporate - Standard Full Time: Mon-Sun 08:00-16:00. Exceptions (off unless hours are given): 2024-08-10 08:00-16:00, 2024-08-17 08:00-16:00, 2024-08-24 08:00-16:00, 2024-08-31 08:00-16:00.

## Resources

| Resource | Group | Unit | Rate |
| --- | --- | --- | --- |
| Operario | labor |  | 3.43 |
| Peón | labor |  | 2.44 |
| Concreto Ciclopeo | material | m3 | 350 |
| Parantes de Madsera de 1 1/2 x 1 1/2" | material | Unid | 8.24 |
| Cinta de Señalización de Peligro | material | Unid | 52.46 |
| Ingeniero Residente de Obra | labor |  |  |
| Ing. SSOMA | labor |  |  |
| Jefe de Topografia | labor |  |  |
| Yeso | material | kg | 1.9 |
| Estacas de Madera | material | Unid | 3.5 |
| Cordel | material | m | 1 |
| Estación Total | equipment |  | 30 |
| Nivel Topografico | equipment |  | 5.3 |
| Herramientas Manuales | equipment |  |  |
| Retroexcavadora Case 590 SK | equipment |  | 185.5 |
| Camión Volquete de 15 m3 | equipment |  | 160 |
| Ing. Responsable de Calidad | labor |  |  |
| Sustrato | material | m3 | 58.35 |
| Zaranda | equipment |  | 6.36 |
| Camión Cisterna (2,500 GLNS.) | equipment |  | 160 |
| Tessaria Integrifolia (Pajaro Bobo) | material | Unid | 15 |
| Baccharis Latifolia (Chilco) | material | Unid | 15 |
| Schinus Molle (Molle) | material | Unid | 22.5 |
| Acacia Macracantha (Huarango) | material | Unid | 22.5 |
| Cal | material | kg | 15.89 |
| Clavos para Madera con Cabeza de 2 1/2" | material | kg | 7 |
| Cola Sintetica | material | gal | 15 |
| Madera Pumaquiro 6" | material | m2 | 30 |
| Insecticida Antitermitas | material | gal | 80 |
| Madera Huayruro | material | P2 | 3.5 |
| Plancha de Acero 8mm | material | kg | 9 |
| Madera Tornillo | material | P2 | 6 |
| Papelera de Reciclaje | material | Unid | 1200 |
| Hormigon | material | m3 | 55.5 |
| Agua Puesta en Obra | material | m3 | 13.5 |
| Banner Señalitica Digital | material | Unid | 90 |
| Cemento Porland Tipo I (42.5 kg) | material | bol | 22.3 |
| Movilización y Desmovilización de Equipos | material | Glob | 5000 |
| Compactadora Vibratoria Tipo Plancha 7 HP | equipment |  | 37.44 |
| Alambre Negro Recocido N° 08 | material | kg | 4.16 |
| Concreto Premezclado F'c = 280 kg/cm2 | material | m3 | 540 |
| Vibrador de Concreto 4 HP 1.25" | equipment |  | 7.27 |
| Perno Hexagonal 1/2" x 17" | material | Unid | 6.5 |
| Arandela Plana de 1/2" | material | Unid | 2.5 |
| Tuerca 1/2" | material | Unid | 2.5 |
| Perno Hexagonal 5/8" x 6" | material | Unid | 7.35 |
| Arandela Plana de 5/8" | material | Unid | 2.75 |
| Tuerca 5/8" | material | Unid | 2.75 |
| Perno Hexagonal 3/4" x 16" | material | Unid | 6.3 |
| Arandela Plana de 3/4" | material | Unid | 2.3 |
| Tuerca 3/4" | material | Unid | 2.3 |
| Perno Hexagonal 1/2" x 6.5" | material | Unid | 6.5 |
| Salix Humboldtina (Sauce) | material | Unid | 30 |
| Alambre Negro Recocido N° 16 | material | kg | 4.16 |
| Malla Rashel | material | m | 10.08 |
| Madera de Eucalipto | material | Unid | 10.17 |
| Ing Especialista en Viveros | labor |  |  |
| Motosierra | equipment |  | 14.2 |
| Especies Arbóreas | material | Unid | 20 |
| Galvezia Fruticosa (Galvezia) | material | Unid | 15 |
| Bougainvellea Peruviana (Buganvilla) | material | Unid | 15 |
| Lippia Nodiflora (Bella Alfombra) | material | m2 |  |
| Material Granular | material | m3 | 55.5 |
| Arena | material | m3 | 68.5 |
| Tronco de Madera | material | Unid | 8 |
| Piedra Chancada 1/2" | material | m3 | 72.03 |
| Arena Gruesa | material | m3 | 63.55 |
| Mezcladora de Concreto 11 P3 (23 HP) | equipment |  | 24 |
| Acero Corrugado fy= 4200 kg/cm2 Grado 60 | material | kg | 4.18 |
| Acero Estructural A36 | material | kg | 13.5 |
| Tornillo Galvanizado D=1/4" Pasante A307 | material | Unid | 8.2 |
| Arandela Plana de 1/4" | material | Unid | 2.5 |
| Tuerca 1/4" | material | Unid | 2.5 |
| Perno de Anclaje de 1/4" Expansivo A307 L=57 mm | material | Unid | 7.5 |
| Perno de Anclaje de 1/4" Expansivo A307 L=114 mm | material | Unid | 12.5 |
| Tubo ASTM A500/A500M | material | m | 14.5 |
| Insecticidas | material | lt | 150 |
| Bombas de funigación | equipment |  |  |
| Erraizante Liquido | material | lt | 85 |
| Fertilizante NPK liberación lenta | material | kg | 3000 |
| Bioestimulantes Foliales | material | lt | 85 |
| Emienda Micorriza | material | kg | 8 |
| Andamio Metalico | equipment |  | 10 |
| Madera Tornillo 3" x 8" | material | Unid | 35 |

## Schedule

| ID | WBS | Activity | Duration | Start | Finish | Predecessors | Total float | Free float | Resources | Cost |
| --- | --- | --- | --- | --- | --- | --- | --- | --- | --- | --- |
| A0900 |  | Inicio de Trabajos | 0d | 2024-08-08 | 2024-08-08 |  | 0d |  |  |  |
|  | 1 | **Infraestructura Verde y Paisajismo - Paquete 01** |  | 2024-08-08 | 2026-01-12 |  |  |  |  |  |
|  | 1 | **Revegetación / Reforestación de La Ribera** |  | 2024-08-08 | 2026-01-12 |  |  |  |  |  |
|  | 1 | **Preparación del Terreno** |  | 2024-08-08 | 2026-01-12 |  |  |  |  |  |
| A1000 |  | Ubicación y Delimitación de la Zona de Trabajo | 5d | 2024-08-08 | 2024-08-12 | A0900 | 0d |  | Operario [56 h]; Peón [56 h]; Concreto Ciclopeo [56 m3]; Parantes de Madsera de 1 1/2 x 1 1/2" [56 Unid]; Cinta de Señalización de Peligro [56 Unid]; Ingeniero Residente de Obra [56 h]; Ing. SSOMA [56 h] | 3,727.71 |
| A1010 |  | Trazado, Marcación y Estacado | 5d | 2024-08-13 | 2024-08-17 | A1000 | 0d |  | Operario [40 h]; Peón [40 h]; Jefe de Topografia [40 h]; Yeso [40 kg]; Estacas de Madera [40 Unid]; Cordel [40 m]; Estación Total [40 h]; Nivel Topografico [40 h]; Herramientas Manuales [40 h]; Ingeniero Residente de Obra [40 h]; Ing. SSOMA [40 h]; Jefe de Topografia | 1,902.65 |
| A1020 |  | Limpieza y Desbroce del Terreno con Medios Manuales | 5d | 2024-08-18 | 2024-08-22 | A1010 | 0d |  | Operario [40 h]; Peón [40 h]; Herramientas Manuales [40 h]; Ingeniero Residente de Obra [40 h]; Ing. SSOMA [40 h] | 234.65 |
| A1030 |  | Eliminación de Materiales de Desbroce (Incuye Transporte) | 1d | 2024-08-23 | 2024-08-23 | A1020 | 0d |  | Ingeniero Residente de Obra [8 h]; Ing. SSOMA [8 h]; Operario [8 h]; Peón [8 h]; Herramientas Manuales [8 h]; Retroexcavadora Case 590 SK [8 h]; Camión Volquete de 15 m3 [8 h] | 2,810.93 |
| A1040 |  | Despedregado del Terreno con Medios Manuales | 5d | 2024-08-24 | 2024-08-28 | A1030 | 0d |  | Ingeniero Residente de Obra [40 h]; Ing. SSOMA [40 h]; Peón [40 h]; Herramientas Manuales [40 h] | 97.55 |
| A1050 |  | Preparación y Aporte del Sustrato | 20d | 2024-11-04 | 2024-11-23 | A1500 FS+60d | 415d |  | Ingeniero Residente de Obra [480 h]; Ing. SSOMA [480 h]; Ing. Responsable de Calidad [480 h]; Operario [480 h]; Peón [480 h]; Sustrato [480 m3]; Zaranda [480 h] | 33,876.6 |
| A1060 |  | Riego de Áreas Vegetadas con Camión Cisterna | 434d | 2024-11-05 | 2026-01-12 | A1070 SS+1d | 0d |  | Ingeniero Residente de Obra; Ing. SSOMA; Operario; Camión Cisterna (2,500 GLNS.) |  |
|  | 2 | **Especies Arbustiva** |  | 2024-11-04 | 2024-12-23 |  |  |  |  |  |
| A1070 |  | Tessaria Integrifolia (Pájaro Bobo) Incluye Siembra y Transporte | 20d | 2024-11-04 | 2024-11-23 | A1500 FS+60d | 0d |  | Ingeniero Residente de Obra [120 h]; Ing. SSOMA [120 h]; Ing. Responsable de Calidad [120 h]; Operario [120 h]; Peón [120 h]; Tessaria Integrifolia (Pajaro Bobo) [120 Unid]; Herramientas Manuales [120 h] | 2,503.95 |
| A1080 |  | Baccharis Latifolia (Chilco) Incluye Siembre y Transporte | 20d | 2024-12-04 | 2024-12-23 | A1500 FS+90d | 385d |  | Ingeniero Residente de Obra [120 h]; Ing. SSOMA [120 h]; Ing. Responsable de Calidad [120 h]; Operario [120 h]; Peón [120 h]; Baccharis Latifolia (Chilco) [120 Unid]; Herramientas Manuales [120 h] | 2,503.95 |
|  | 3 | **Especies Arbóreas** |  | 2025-09-05 | 2025-09-24 |  |  |  |  |  |
| A1090 |  | Shinus Molle (Molle) Incuye Siembra y Transporte | 20d | 2025-09-05 | 2025-09-24 | A1500 FS+365d | 110d |  | Ingeniero Residente de Obra [120 h]; Ing. SSOMA [120 h]; Ing. Responsable de Calidad [120 h]; Operario [120 h]; Peón [120 h]; Schinus Molle (Molle) [120 Unid]; Herramientas Manuales [120 h] | 3,403.95 |
| A1100 |  | Acacia Macracantha (Huarango) Incluye Siembra Y Transporte | 20d | 2025-09-05 | 2025-09-24 | A1500 FS+365d | 110d |  | Ingeniero Residente de Obra [120 h]; Ing. SSOMA [120 h]; Ing. Responsable de Calidad [120 h]; Operario [120 h]; Peón [120 h]; Acacia Macracantha (Huarango) [120 Unid]; Herramientas Manuales [120 h] | 3,403.95 |
|  | 6 | **Arquitectura** |  | 2024-09-05 | 2024-09-30 |  |  |  |  |  |
|  | 1 | **Preparación del Terreno** |  | 2024-09-05 | 2024-09-10 |  |  |  |  |  |
| A1110 |  | Ubicación Y Delimitación De La Zona De Trabajo | 3d | 2024-09-05 | 2024-09-07 | A1500 | 425d | 0d | Ingeniero Residente de Obra [24 h]; Ing. SSOMA [24 h]; Operario [24 h]; Peón [24 h]; Concreto Ciclopeo [24 m3]; Parantes de Madsera de 1 1/2 x 1 1/2" [24 Unid]; Cinta de Señalización de Peligro [24 Unid] | 1,597.59 |
| A1120 |  | Limpieza Y Desbroce Del Terreno Con Medios Manuales | 3d | 2024-09-05 | 2024-09-07 | A1110 SS | 425d | 0d | Ingeniero Residente de Obra [24 h]; Ing. SSOMA [24 h]; Operario [24 h]; Peón [24 h]; Herramientas Manuales [24 h] | 140.79 |
| A1140 |  | Despedregado Del Terreno Con Medios Manuales | 5d | 2024-09-06 | 2024-09-10 | A1120 SS+1d | 425d | 0d | Ingeniero Residente de Obra [40 h]; Ing. SSOMA [40 h]; Peón [40 h]; Herramientas Manuales [40 h] | 97.55 |
| A1130 |  | Eliminación De Materiales De Desbroce (Incluye Transporte) | 1d | 2024-09-08 | 2024-09-08 | A1120 | 491d |  | Ingeniero Residente de Obra [8 h]; Ing. SSOMA [8 h]; Operario [8 h]; Peón [8 h]; Herramientas Manuales [8 h]; Retroexcavadora Case 590 SK [8 h]; Camión Volquete de 15 m3 [8 h] | 2,810.93 |
|  | 2 | **Trabajos Provisionales** |  | 2024-09-11 | 2024-09-12 |  |  |  |  |  |
| A1150 |  | Trazado Y Replanteo S/Equipo Con Cal Blanca | 2d | 2024-09-11 | 2024-09-12 | A1140 | 425d | 0d | Ingeniero Residente de Obra [16 h]; Ing. SSOMA [16 h]; Operario [16 h]; Peón [16 h]; Cal [16 kg]; Estacas de Madera [16 Unid]; Herramientas Manuales [16 h] | 404.1 |

| ID | WBS | Activity | Duration | Start | Finish | Predecessors | Total float | Free float | Resources | Cost |
| --- | --- | --- | --- | --- | --- | --- | --- | --- | --- | --- |
|  | 3 | **Pasarela** |  | 2024-09-13 | 2024-09-24 |  |  |  |  |  |
| A1160 |  | Piso Entablado De Madera De Sección 1” X 6” Para Pasarela Elevada | 12d | 2024-09-13 | 2024-09-24 | A1150 | 469d | 0d | Ingeniero Residente de Obra [96 h]; Ing. SSOMA [96 h]; Ing. Responsable de Calidad [96 h]; Operario [96 h]; Peón [96 h]; Clavos para Madera con Cabeza de 2 1/2" [96 kg]; Cola Sintetica [96 gal]; Madera Pumaquiro 6" [96 m2]; Insecticida Antitermitas [96 gal]; Herramientas Manuales [96 h] | 13,235.16 |
| A1170 |  | Baranda De Madera De Huayruro De H=1.00 M, Para Pasarela | 12d | 2024-09-13 | 2024-09-24 | A1160 SS | 469d | 0d | Ingeniero Residente de Obra [96 h]; Ing. SSOMA [96 h]; Ing. Responsable de Calidad [96 h]; Operario [96 h]; Peón [96 h]; Clavos para Madera con Cabeza de 2 1/2" [96 kg]; Madera Huayruro [96 P2]; Insecticida Antitermitas [96 gal]; Herramientas Manuales [96 h] | 9,251.16 |
|  | 4 | **Mobiliario Urbano** |  | 2024-09-25 | 2024-09-30 |  |  |  |  |  |
| A1180 |  | Bancas De Madera Con Respaldar. Tipo T1 | 3d | 2024-09-25 | 2024-09-27 | A1170 | 469d | 0d | Ingeniero Residente de Obra [24 h]; Ing. SSOMA [24 h]; Ing. Responsable de Calidad [24 h]; Operario [24 h]; Peón [24 h]; Clavos para Madera con Cabeza de 2 1/2" [24 kg]; Plancha de Acero 8mm [24 kg]; Madera Tornillo [24 P2]; Insecticida Antitermitas [24 gal] | 2,588.79 |
| A1190 |  | Papeleras De Reciclaje De Acabado De Madera En Estructura De 4 (75 Litros C/U) | 1d | 2024-09-28 | 2024-09-28 | A1180 | 469d | 0d | Ingeniero Residente de Obra [8 h]; Ing. SSOMA [8 h]; Operario [8 h]; Peón [8 h]; Herramientas Manuales [8 h]; Papelera de Reciclaje [8 Unid] | 9,646.93 |
| A1200 |  | Panel Informativo H=1.25m. Tipo A | 2d | 2024-09-29 | 2024-09-30 | A1190 | 469d |  | Ingeniero Residente de Obra [16 h]; Ing. SSOMA [16 h]; Ing. Responsable de Calidad [16 h]; Operario [16 h]; Peón [16 h]; Clavos para Madera con Cabeza de 2 1/2" [16 kg]; Hormigon [16 m3]; Agua Puesta en Obra [16 m3]; Banner Señalitica Digital [16 Unid]; Cemento Porland Tipo I (42.5 kg) [16 bol]; Madera Tornillo [16 P2]; Herramientas Manuales [16 h] | 3,202.66 |
| A1210 |  | Panel Informativo H=2.10m. Tipo B | 2d | 2024-09-29 | 2024-09-30 | A1190 SS+1d | 469d |  | Ingeniero Residente de Obra [16 h]; Ing. SSOMA [16 h]; Ing. Responsable de Calidad [16 h]; Operario [16 h]; Peón [16 h]; Clavos para Madera con Cabeza de 2 1/2" [16 kg]; Hormigon [16 m3]; Agua Puesta en Obra [16 m3]; Banner Señalitica Digital [16 Unid]; Cemento Porland Tipo I (42.5 kg) [16 bol]; Madera Tornillo [16 P2]; Herramientas Manuales [16 h] | 3,202.66 |
|  | 5 | **Pasarela - Elementos Estructurales** |  | 2024-08-08 | 2024-11-13 |  |  |  |  |  |
|  | 1 | **Trabajos Preliminares** |  | 2024-09-11 | 2024-09-19 |  |  |  |  |  |
| A1220 |  | Trazo, Nivelacion Y Replanteo En Pasarela | 6d | 2024-09-11 | 2024-09-16 | A1150 SS | 425d | 0d | Ingeniero Residente de Obra [48 h]; Ing. SSOMA [48 h]; Ing. Responsable de Calidad [48 h]; Jefe de Topografia [48 h]; Nivel Topografico [48 h]; Yeso [48 kg]; Cordel [48 m]; Estación Total [48 h]; Herramientas Manuales [48 h] | 1,833.6 |
| A1230 |  | Movilización Y Desmovilización De Equipos | 3d | 2024-09-17 | 2024-09-19 | A1220 | 480d |  | Ingeniero Residente de Obra [24 h]; Movilización y Desmovilización de Equipos [24 Glob] | 120,000 |
|  | 2 | **Movimiento de Tierras** |  | 2024-09-17 | 2024-09-19 |  |  |  |  |  |
| A1240 |  | Excavación Con Maquinaria | 2d | 2024-09-17 | 2024-09-18 | A1220 | 425d | 0d | Ingeniero Residente de Obra [16 h]; Ing. SSOMA [16 h]; Operario [16 h]; Herramientas Manuales [16 h]; Retroexcavadora Case 590 SK [16 h] | 3,022.84 |
| A1250 |  | Acarreo Y Eliminación De Material Excedente | 1d | 2024-09-19 | 2024-09-19 | A1240 | 425d | 0d | Ingeniero Residente de Obra [8 h]; Ing. SSOMA [8 h]; Operario [8 h]; Peón [8 h]; Herramientas Manuales [8 h]; Retroexcavadora Case 590 SK [8 h]; Camión Volquete de 15 m3 [8 h] | 2,810.93 |
|  | 3 | **Rellenos** |  | 2024-09-20 | 2024-09-26 |  |  |  |  |  |
| A1260 |  | Relleno Con Material Propio | 7d | 2024-09-20 | 2024-09-26 | A1250 | 425d | 0d | Ingeniero Residente de Obra [56 h]; Ing. SSOMA [56 h]; Operario [56 h]; Peón [56 h]; Herramientas Manuales [56 h]; Compactadora Vibratoria Tipo Plancha 7 HP [56 h] | 2,425.15 |
|  | 4 | **Obras de Concreto Simple** |  | 2024-09-27 | 2024-10-07 |  |  |  |  |  |
| A1270 |  | Encofrado y Desencofrado en Pilotes | 9d | 2024-09-27 | 2024-10-05 | A1260 | 425d | 0d | Ingeniero Residente de Obra [72 h]; Ing. SSOMA [72 h]; Operario [72 h]; Peón [72 h]; Alambre Negro Recocido N° 08 [72 kg]; Clavos para Madera con Cabeza de 2 1/2" [72 kg]; Madera Tornillo [72 P2]; Herramientas Manuales [72 h] | 1,657.89 |
| A1280 |  | Concreto Para Pilotes F'c=28 Mpa | 2d | 2024-10-06 | 2024-10-07 | A1270 | 425d | 0d | Ingeniero Residente de Obra [16 h]; Ing. SSOMA [16 h]; Ing. Responsable de Calidad [16 h]; Operario [16 h]; Peón [16 h]; Concreto Premezclado F'c = 280 kg/cm2 [16 m3]; Herramientas Manuales [16 h]; Vibrador de Concreto 4 HP 1.25" [16 h] | 8,850.18 |
|  | 5 | **Carpinteria de Madera** |  | 2024-10-08 | 2024-11-13 |  |  |  |  |  |
| A1290 |  | Columna De Ø 8" | 7d | 2024-10-08 | 2024-10-14 | A1280 | 425d | 0d | Herramientas Manuales [56 h]; Ingeniero Residente de Obra [56 h]; Ing. SSOMA [56 h]; Ing. Responsable de Calidad [56 h]; Operario [56 h]; Peón [56 h]; Madera Tornillo [56 P2] | 664.51 |
| A1300 |  | Viga De 3"X10" | 10d | 2024-10-15 | 2024-10-24 | A1290 | 425d | 0d | Herramientas Manuales [80 h]; Ingeniero Residente de Obra [80 h]; Ing. SSOMA [80 h]; Ing. Responsable de Calidad [80 h]; Operario [80 h]; Peón [80 h]; Madera Tornillo [80 P2]; Andamio Metalico [80 h] | 1,749.3 |
| A1310 |  | Larguero De 2"X10" | 15d | 2024-10-25 | 2024-11-08 | A1300 | 425d | 0d | Herramientas Manuales [120 h]; Ingeniero Residente de Obra [120 h]; Ing. SSOMA [120 h]; Operario [120 h]; Peón [120 h]; Madera Tornillo [120 P2]; Andamio Metalico [120 h] | 2,623.95 |
| A1320 |  | Arriostres De 3"X8" | 15d | 2024-10-30 | 2024-11-13 | A1310 SS+5d | 425d |  | Herramientas Manuales [120 h]; Ingeniero Residente de Obra [120 h]; Ing. SSOMA [120 h]; Operario [120 h]; Peón [120 h]; Madera Tornillo 3" x 8" [120 Unid]; Andamio Metalico [120 h] | 6,103.95 |

| ID | WBS | Activity | Duration | Start | Finish | Predecessors | Total float | Free float | Resources | Cost |
| --- | --- | --- | --- | --- | --- | --- | --- | --- | --- | --- |
|  | 6 | **Accesorios Metalicos** |  | 2024-08-08 | 2024-10-06 |  |  |  |  |  |
| A1330 |  | Perno Hexagonal 1/2"X17" + 2 Tuercas + 2 Arandelas | 15d | 2024-08-08 | 2024-08-22 |  | 458d | 0d | Ingeniero Residente de Obra [120 h]; Ing. SSOMA [120 h]; Operario [120 h]; Perno Hexagonal 1/2" x 17" [120 Unid]; Arandela Plana de 1/2" [120 Unid]; Tuerca 1/2" [120 Unid]; Herramientas Manuales [120 h] | 1,791.3 |
| A1340 |  | Perno Hexagonal 5/8"X6" + 2 Tuercas + 2 Arandelas | 15d | 2024-08-23 | 2024-09-06 | A1330 | 458d | 0d | Ingeniero Residente de Obra [120 h]; Ing. SSOMA [120 h]; Operario [120 h]; Perno Hexagonal 5/8" x 6" [120 Unid]; Arandela Plana de 5/8" [120 Unid]; Tuerca 5/8" [120 Unid]; Herramientas Manuales [120 h] | 1,953.3 |
| A1350 |  | Perno Hexagonal 3/4"X16" + 2 Tuercas + 2 Arandelas | 15d | 2024-09-07 | 2024-09-21 | A1340 | 458d | 0d | Ingeniero Residente de Obra [120 h]; Ing. SSOMA [120 h]; Operario [120 h]; Perno Hexagonal 3/4" x 16" [120 Unid]; Arandela Plana de 3/4" [120 Unid]; Tuerca 3/4" [120 Unid]; Herramientas Manuales [120 h] | 1,719.3 |
| A1360 |  | Perno Hexagonal 1/2"X6.5" + 2 Tuercas + 2 Arandelas | 15d | 2024-09-22 | 2024-10-06 | A1350 | 458d | 0d | Ingeniero Residente de Obra [120 h]; Ing. SSOMA [120 h]; Operario [120 h]; Perno Hexagonal 1/2" x 6.5" [120 Unid]; Arandela Plana de 1/2" [120 Unid]; Tuerca 1/2" [120 Unid]; Herramientas Manuales [120 h] | 1,791.3 |
|  | 7 | **Varios** |  | 2024-10-07 | 2024-10-11 |  |  |  |  |  |
| A1370 |  | Limpieza Final de Obra | 5d | 2024-10-07 | 2024-10-11 | A1360 | 458d |  | Ingeniero Residente de Obra [40 h]; Ing. SSOMA [40 h]; Operario [40 h]; Peón [40 h]; Herramientas Manuales [40 h] | 234.65 |
|  | 8 | **Mantenimiento Post Plantación** |  | 2024-11-05 | 2026-01-12 |  |  |  |  |  |
|  | 1 | **Mantenimiento de Vegetación Arborea** |  | 2024-11-05 | 2026-01-12 |  |  |  |  |  |
| A2290 |  | Deshierbe | 434d | 2024-11-05 | 2026-01-12 | A1070 SS+1d | 0d |  | Ingeniero Residente de Obra; Ing. SSOMA; Operario; Herramientas Manuales |  |
| A2300 |  | Control de Plagas | 434d | 2024-11-05 | 2026-01-12 | A1070 SS+1d | 0d |  | Ingeniero Residente de Obra; Ing. SSOMA; Operario; Insecticidas; Bombas de funigación |  |
| A2310 |  | Poda | 434d | 2024-11-05 | 2026-01-12 | A1070 SS+1d | 0d |  | Ingeniero Residente de Obra; Ing. SSOMA; Operario; Herramientas Manuales |  |
| A2320 |  | Recalce | 434d | 2024-11-05 | 2026-01-12 | A1070 SS+1d | 0d |  | Ingeniero Residente de Obra; Ing. SSOMA; Operario; Herramientas Manuales |  |
|  | 2 | **Mantenimiento de Vegetación Arbustiva** |  | 2024-11-05 | 2026-01-12 |  |  |  |  |  |
| A2240 |  | Deshierne | 434d | 2024-11-05 | 2026-01-12 | A1070 SS+1d | 0d |  | Herramientas Manuales; Ingeniero Residente de Obra; Ing. SSOMA; Operario |  |
| A2250 |  | Recalce | 434d | 2024-11-05 | 2026-01-12 | A1070 SS+1d | 0d |  | Ingeniero Residente de Obra; Ing. SSOMA; Operario; Herramientas Manuales |  |
|  | 3 | **Bioestimulación** |  | 2024-11-05 | 2026-01-12 |  |  |  |  |  |
| A2330 |  | Aplicación de Enraizante | 434d | 2024-11-05 | 2026-01-12 | A1070 SS+1d | 0d |  | Ingeniero Residente de Obra; Ing. SSOMA; Operario; Bombas de funigación; Erraizante Liquido |  |
|  | 4 | **Fertilización Quimica** |  | 2024-11-05 | 2026-01-12 |  |  |  |  |  |
| A2340 |  | Fertilización de liberación lenta NPK | 434d | 2024-11-05 | 2026-01-12 | A1070 SS+1d | 0d |  | Ingeniero Residente de Obra; Ing. SSOMA; Operario; Herramientas Manuales; Fertilizante NPK liberación lenta |  |
| A2350 |  | Aplicación Foliar bioestimulantes | 434d | 2024-11-05 | 2026-01-12 | A1070 SS+1d | 0d |  | Ingeniero Residente de Obra; Ing. SSOMA; Operario; Bombas de funigación; Bioestimulantes Foliales |  |
|  | 5 | **Aplicación de Micorrizas** |  | 2024-11-05 | 2026-01-12 |  |  |  |  |  |
| A2360 |  | Aplicación de Micorrizas | 434d | 2024-11-05 | 2026-01-12 | A1070 SS+1d | 0d |  | Ingeniero Residente de Obra; Ing. SSOMA; Operario; Herramientas Manuales; Emienda Micorriza |  |
|  | 6 | **Monitoreo de Plantaciones** |  | 2024-11-05 | 2026-01-12 |  |  |  |  |  |
| A2370 |  | Monitoreo de Plantaciones | 434d | 2024-11-05 | 2026-01-12 | A1070 SS+1d | 0d |  | Ingeniero Residente de Obra; Ing. SSOMA; Operario |  |

| ID | WBS | Activity | Duration | Start | Finish | Predecessors | Total float | Resources | Cost |
| --- | --- | --- | --- | --- | --- | --- | --- | --- | --- |
|  | 2 | **Infraestructura Verde y Paisajismo - Paquete 02 - Parte 01** |  | 2024-08-08 | 2026-01-12 |  |  |  |  |
|  | 1 | **Revegetación / Reforestación De La Ribera** |  | 2024-08-08 | 2026-01-12 |  |  |  |  |
|  | 1 | **Preparación Del Terreno** |  | 2024-08-08 | 2026-01-12 |  |  |  |  |
| A1380 |  | Ubicación Y Delimitación De La Zona De Trabajo | 5d | 2024-08-08 | 2024-08-12 | A0900 | 0d | Ingeniero Residente de Obra [40 h]; Ing. SSOMA [40 h]; Operario [40 h]; Peón [40 h]; Concreto Ciclopeo [40 m3]; Parantes de Madsera de 1 1/2 x 1 1/2" [40 Unid]; Cinta de Señalización de Peligro [40 Unid] | 2,662.65 |
| A1390 |  | Trazado, Marcación Y Estacado | 5d | 2024-08-13 | 2024-08-17 | A1380 | 0d | Ingeniero Residente de Obra [40 h]; Ing. SSOMA [40 h]; Operario [40 h]; Peón [40 h]; Jefe de Topografia [40 h]; Yeso [40 kg]; Estacas de Madera [40 Unid]; Cordel [40 m]; Estación Total [40 h]; Nivel Topografico [40 h]; Herramientas Manuales [40 h] | 1,902.65 |
| A1400 |  | Limpieza Y Desbroce Del Terreno Con Medios Manuales | 5d | 2024-08-18 | 2024-08-22 | A1390 | 0d | Ingeniero Residente de Obra [40 h]; Ing. SSOMA [40 h]; Operario [40 h]; Peón [40 h]; Herramientas Manuales [40 h] | 234.65 |
| A1410 |  | Eliminación De Materiales De Desbroce (Incluye Transporte) | 1d | 2024-08-23 | 2024-08-23 | A1400 | 0d | Ingeniero Residente de Obra [32 h]; Ing. SSOMA [32 h]; Operario [32 h]; Peón [32 h]; Herramientas Manuales [32 h]; Retroexcavadora Case 590 SK [32 h]; Camión Volquete de 15 m3 [32 h] | 11,243.72 |
| A1420 |  | Despedregado Del Terreno Con Medios Manuales | 5d | 2024-08-24 | 2024-08-28 | A1410 | 0d | Ingeniero Residente de Obra [96 h]; Ing. SSOMA [96 h]; Peón [96 h]; Herramientas Manuales [96 h] | 234.12 |
| A1430 |  | Preparación Y Aporte Del Sustrato | 20d | 2024-11-04 | 2024-11-23 | A1500 FS+60d | 415d | Ingeniero Residente de Obra [720 h]; Ing. SSOMA [720 h]; Ing. Responsable de Calidad [720 h]; Operario [720 h]; Peón [720 h]; Sustrato [720 m3]; Herramientas Manuales [720 h]; Zaranda [720 h] | 50,814.9 |
| A1440 |  | Riego De Áreas Vegetadas Con Camión Cisterna | 434d | 2024-11-05 | 2026-01-12 | A1070 SS+1d | 0d | Ingeniero Residente de Obra [720 h]; Ing. SSOMA [720 h]; Operario [720 h]; Camión Cisterna (2,500 GLNS.) [720 h] | 117,667.8 |
|  | 2 | **Especies Arbustivas** |  | 2024-11-04 | 2024-12-23 |  |  |  |  |
| A1450 |  | Tessaria Integrifolia (Pájaro Bobo) Incluye Siembra Y Transporte | 20d | 2024-11-04 | 2024-11-23 | A1500 FS+60d | 415d | Ingeniero Residente de Obra [200 h]; Ing. SSOMA [200 h]; Ing. Responsable de Calidad [200 h]; Operario [200 h]; Peón [200 h]; Tessaria Integrifolia (Pajaro Bobo) [200 Unid]; Herramientas Manuales [200 h] | 4,173.25 |
| A1460 |  | Baccharis Latifolia (Chilco) Incluye Siembra Y Transporte | 20d | 2024-12-04 | 2024-12-23 | A1500 FS+90d | 385d | Ingeniero Residente de Obra [200 h]; Ing. SSOMA [200 h]; Ing. Responsable de Calidad [200 h]; Operario [200 h]; Peón [200 h]; Baccharis Latifolia (Chilco) [200 Unid]; Herramientas Manuales [200 h] | 4,173.25 |
|  | 3 | **Especies Arbóreas** |  | 2025-06-02 | 2025-09-24 |  |  |  |  |
| A1490 |  | Salix Humboldtiana (Sauce) Incluye Siembra Y Transporte | 20d | 2025-06-02 | 2025-06-21 | A1500 FS+270d | 0d | Ingeniero Residente de Obra [120 h]; Ing. SSOMA [120 h]; Ing. Responsable de Calidad [120 h]; Operario [120 h]; Peón [120 h]; Salix Humboldtina (Sauce) [120 Unid]; Herramientas Manuales [120 h] | 4,303.95 |
| A1470 |  | Schinus Molle (Molle) Incluye Siembra Y Transporte | 20d | 2025-09-05 | 2025-09-24 | A1500 FS+365d | 110d | Ingeniero Residente de Obra [160 h]; Ing. SSOMA [160 h]; Ing. Responsable de Calidad [160 h]; Operario [160 h]; Peón [160 h]; Schinus Molle (Molle) [160 Unid]; Herramientas Manuales [160 h] | 4,538.6 |
| A1480 |  | Acacia Macracantha (Huarango) Incluye Siembra Y Transporte | 20d | 2025-09-05 | 2025-09-24 | A1500 FS+365d | 110d | Ingeniero Residente de Obra [160 h]; Ing. SSOMA [160 h]; Ing. Responsable de Calidad [160 h]; Operario [160 h]; Peón [160 h]; Acacia Macracantha (Huarango) [160 Unid]; Herramientas Manuales [160 h] | 4,538.6 |
|  | 4 | **Vivero Temporal** |  | 2024-08-29 | 2024-09-04 |  |  |  |  |
| A1500 |  | Implementación De Vivero Temporal | 7d | 2024-08-29 | 2024-09-04 | A1040, A1420, A1790 | 0d | Herramientas Manuales [728 h]; Ingeniero Residente de Obra [728 h]; Ing. SSOMA [728 h]; Peón [728 h]; Alambre Negro Recocido N° 16 [728 kg]; Clavos para Madera con Cabeza de 2 1/2" [728 kg]; Malla Rashel [728 m]; Madera de Eucalipto [728 Unid]; Ing Especialista en Viveros [56 h] | 24,641.89 |
|  | 5 | **Mantenimiento Post Plantación** |  | 2025-06-03 | 2026-01-12 |  |  |  |  |
|  | 2 | **Mantenimiento de Vegetación Arbolea** |  | 2025-06-03 | 2026-01-12 |  |  |  |  |
| A2420 |  | Deshierbe | 224d | 2025-06-03 | 2026-01-12 | A1490 SS+1d | 0d | Ingeniero Residente de Obra [2920 h]; Ing. SSOMA [2920 h]; Operario [2920 h]; Herramientas Manuales [2920 h] | 10,008.3 |
| A2430 |  | Control de Plagas | 224d | 2025-06-03 | 2026-01-12 | A1490 SS+1d | 0d | Ingeniero Residente de Obra [2152 h]; Ing. SSOMA [2152 h]; Operario [2152 h]; Bombas de funigación [2152 h]; Insecticidas [2152 lt] | 330,175.98 |
| A2440 |  | Poda | 224d | 2025-06-03 | 2026-01-12 | A1490 SS+1d | 0d | Herramientas Manuales [2152 h]; Ingeniero Residente de Obra [2152 h]; Ing. SSOMA [2152 h]; Operario [2152 h] | 7,375.98 |
| A2450 |  | Recalce | 224d | 2025-06-03 | 2026-01-12 | A1490 SS+1d | 0d | Ingeniero Residente de Obra [2152 h]; Ing. SSOMA [2152 h]; Operario [2152 h]; Herramientas Manuales [2152 h] | 7,375.98 |

| ID | WBS | Activity | Duration | Start | Finish | Predecessors | Total float | Free float | Resources | Cost |
| --- | --- | --- | --- | --- | --- | --- | --- | --- | --- | --- |
|  | 1 | **Mantenimiento de Vegetación Arbustiva** |  | 2025-06-03 | 2026-01-12 |  |  |  |  |  |
| A2380 |  | Deshierbe | 224d | 2025-06-03 | 2026-01-12 | A1490 SS+1d | 0d |  | Ingeniero Residente de Obra [656 h]; Ing. SSOMA [656 h]; Operario [656 h]; Herramientas Manuales [656 h] | 2,248.44 |
| A2410 |  | Recalce | 224d | 2025-06-03 | 2026-01-12 | A1490 SS+1d | 0d |  | Herramientas Manuales [656 h]; Ingeniero Residente de Obra [656 h]; Ing. SSOMA [656 h]; Operario [656 h] | 2,248.44 |
|  | 3 | **Bioestimulación** |  | 2025-06-03 | 2026-01-12 |  |  |  |  |  |
| A2460 |  | Aplicación de Enraizante | 224d | 2025-06-03 | 2026-01-12 | A1490 SS+1d | 0d |  | Ingeniero Residente de Obra [656 h]; Ing. SSOMA [656 h]; Operario [656 h]; Erraizante Liquido [656 lt]; Bombas de funigación [656 h] | 58,008.44 |
|  | 5 | **Fertilización Quimica** |  | 2025-06-03 | 2026-01-12 |  |  |  |  |  |
| A2470 |  | Fertilización de liberación lenta NPK | 224d | 2025-06-03 | 2026-01-12 | A1490 SS+1d | 0d |  | Ingeniero Residente de Obra [656 h]; Ing. SSOMA [656 h]; Operario [656 h]; Fertilizante NPK liberación lenta [656 kg]; Herramientas Manuales [656 h] | 1,970,248.44 |
| A2480 |  | Aplicación Foliar Bioestimulantes | 224d | 2025-06-03 | 2026-01-12 | A1490 SS+1d | 0d |  | Ingeniero Residente de Obra [656 h]; Ing. SSOMA [656 h]; Operario [656 h]; Bioestimulantes Foliales [656 lt]; Bombas de funigación [656 h] | 58,008.44 |
|  | 6 | **Aplicación de Micorrizas** |  | 2025-06-03 | 2026-01-12 |  |  |  |  |  |
| A2490 |  | Aplicación de Micorrizas | 224d | 2025-06-03 | 2026-01-12 | A1490 SS+1d | 0d |  | Ingeniero Residente de Obra [240 h]; Ing. SSOMA [240 h]; Operario [240 h]; Emienda Micorriza [240 kg]; Herramientas Manuales [240 h] | 2,742.6 |
|  | 7 | **Monitoreo de Plantaciones** |  | 2025-06-03 | 2026-01-12 |  |  |  |  |  |
| A2500 |  | Monitoreo de Plantaciones | 224d | 2025-06-03 | 2026-01-12 | A1490 SS+1d | 0d |  | Ingeniero Residente de Obra [2152 h]; Ing. SSOMA [2152 h]; Operario [2152 h] | 7,375.98 |
|  | 3 | **Infraestructura Verde y Paisajismo - Paquete 02 - Parte 02** |  | 2024-08-08 | 2026-01-12 |  |  |  |  |  |
|  | 1 | **Revegetación / Reforestación De La Ribera** |  | 2024-08-08 | 2026-01-12 |  |  |  |  |  |
|  | 1 | **Preparación Del Terreno** |  | 2024-08-08 | 2026-01-12 |  |  |  |  |  |
| A1510 |  | Ubicación Y Delimitación De La Zona De Trabajo | 5d | 2024-08-08 | 2024-08-12 | A0900 | 502d | 0d | Ingeniero Residente de Obra [40 h]; Ing. SSOMA [40 h]; Operario [40 h]; Peón [40 h]; Concreto Ciclopeo [40 m3]; Parantes de Madsera de 1 1/2 x 1 1/2" [40 Unid]; Cinta de Señalización de Peligro [40 Unid] | 2,662.65 |
| A1520 |  | Trazado, Marcación Y Estacado | 5d | 2024-08-13 | 2024-08-17 | A1510 | 502d | 0d | Ingeniero Residente de Obra [40 h]; Ing. SSOMA [40 h]; Jefe de Topografia [40 h]; Operario [40 h]; Peón [40 h]; Yeso [40 kg]; Estacas de Madera [40 Unid]; Cordel [40 m]; Estación Total [40 h]; Nivel Topografico [40 h]; Herramientas Manuales [40 h] | 1,902.65 |
| A1530 |  | Limpieza Y Desbroce Del Terreno Con Medios Manuales | 5d | 2024-08-18 | 2024-08-22 | A1520 | 502d | 0d | Herramientas Manuales [40 h]; Ingeniero Residente de Obra [40 h]; Ing. SSOMA [40 h]; Operario [40 h]; Peón [40 h] | 234.65 |
| A1540 |  | Eliminación De Materiales De Desbroce (Incluye Transporte) | 1d | 2024-08-23 | 2024-08-23 | A1530 | 502d | 0d | Ing. SSOMA [16 h]; Ingeniero Residente de Obra [16 h]; Operario [16 h]; Peón [16 h]; Herramientas Manuales [16 h]; Retroexcavadora Case 590 SK [16 h]; Camión Volquete de 15 m3 [16 h] | 5,621.86 |
| A1550 |  | Despedregado Del Terreno Con Medios Manuales | 5d | 2024-08-24 | 2024-08-28 | A1540 | 502d |  | Ingeniero Residente de Obra [16 h]; Ing. SSOMA [16 h]; Peón [16 h]; Herramientas Manuales [16 h] | 39.02 |
| A1560 |  | Preparación Y Aporte Del Sustrato | 20d | 2024-11-04 | 2024-11-23 | A1500 FS+60d | 415d |  | Herramientas Manuales [320 h]; Ingeniero Residente de Obra [320 h]; Ing. SSOMA [320 h]; Ing. Responsable de Calidad [320 h]; Sustrato [320 m3]; Zaranda [320 h] | 20,707.2 |
| A1570 |  | Riego De Áreas Vegetadas Con Camión Cisterna | 204d | 2025-06-23 | 2026-01-12 | A1600 FS+1d | 0d |  | Ingeniero Residente de Obra [720 h]; Ing. SSOMA [720 h]; Operario [720 h]; Camión Cisterna (2,500 GLNS.) [720 h] | 117,667.8 |
|  | 2 | **Especies Arbóreas** |  | 2025-06-02 | 2025-09-24 |  |  |  |  |  |
| A1600 |  | Salix Humboldtiana (Sauce) Incluye Siembra Y Transporte | 20d | 2025-06-02 | 2025-06-21 | A1500 FS+270d | 0d |  | Ingeniero Residente de Obra [144 h]; Ing. SSOMA [144 h]; Ing. Responsable de Calidad [144 h]; Operario [144 h]; Peón [144 h]; Salix Humboldtina (Sauce) [144 Unid]; Herramientas Manuales [144 h] | 5,164.74 |
| A1580 |  | Schinus Molle (Molle) Incluye Siembra Y Transporte | 20d | 2025-09-05 | 2025-09-24 | A1500 FS+365d | 110d |  | Ingeniero Residente de Obra [144 h]; Ing. SSOMA [144 h]; Ing. Responsable de Calidad [144 h]; Operario [144 h]; Peón [144 h]; Schinus Molle (Molle) [144 Unid]; Herramientas Manuales [144 h] | 4,084.74 |
| A1590 |  | Acacia Macracantha (Huarango) Incluye Siembra Y Transporte | 20d | 2025-09-05 | 2025-09-24 | A1500 FS+365d | 110d |  | Herramientas Manuales [144 h]; Ingeniero Residente de Obra [144 h]; Ing. SSOMA [144 h]; Ing. Responsable de Calidad [144 h]; Operario [144 h]; Peón [144 h]; Acacia Macracantha (Huarango) [144 Unid] | 4,084.74 |

| ID | WBS | Activity | Duration | Start | Finish | Predecessors | Total float | Free float | Resources | Cost |
| --- | --- | --- | --- | --- | --- | --- | --- | --- | --- | --- |
|  | 3 | **Mantenimiento Post Plantación** |  | 2025-06-03 | 2026-01-12 |  |  |  |  |  |
|  | 1 | **Mantenimienot de Vegetación Arborea** |  | 2025-06-03 | 2026-01-12 |  |  |  |  |  |
| A2510 |  | Deshierbe | 224d | 2025-06-03 | 2026-01-12 | A1600 SS+1d | 0d |  | Ingeniero Residente de Obra [2112 h]; Ing. SSOMA [2112 h]; Operario [2112 h]; Herramientas Manuales [2112 h] | 7,238.88 |
| A2520 |  | Control de Plagas | 224d | 2025-06-03 | 2026-01-12 | A1600 SS+1d | 0d |  | Insecticidas [1560 lt]; Ingeniero Residente de Obra [1560 h]; Ing. SSOMA [1560 h]; Operario [1560 h]; Bombas de funigación [1560 h] | 239,346.9 |
| A2530 |  | Poda | 224d | 2025-06-03 | 2026-01-12 | A1600 SS+1d | 0d |  | Herramientas Manuales [1560 h]; Ingeniero Residente de Obra [1560 h]; Ing. SSOMA [1560 h]; Operario [1560 h] | 5,346.9 |
| A2540 |  | Recalce | 224d | 2025-06-03 | 2026-01-12 | A1600 SS+1d | 0d |  | Ingeniero Residente de Obra [1560 h]; Ing. SSOMA [1560 h]; Operario [1560 h]; Herramientas Manuales [1560 h] | 5,346.9 |
|  | 2 | **Bioestimulación** |  | 2025-06-03 | 2026-01-12 |  |  |  |  |  |
| A2570 |  | Aplicación de Enraizante | 224d | 2025-06-03 | 2026-01-12 | A1600 SS+1d | 0d |  | Bombas de funigación [1416 h]; Ingeniero Residente de Obra [1416 h]; Ing. SSOMA [1416 h]; Operario [1416 h]; Erraizante Liquido [1416 lt] | 125,213.34 |
|  | 4 | **Fertilización Quimica** |  | 2025-06-03 | 2026-01-12 |  |  |  |  |  |
| A2580 |  | Fertilización de líberación lenta NPK | 224d | 2025-06-03 | 2026-01-12 | A1600 SS+1d | 0d |  | Ingeniero Residente de Obra [1416 h]; Ing. SSOMA [1416 h]; Operario [1416 h]; Herramientas Manuales [1416 h]; Fertilizante NPK liberación lenta [1416 kg] | 4,252,853.34 |
| A2590 |  | Apliación Foliar Bioestimulantes | 224d | 2025-06-03 | 2026-01-12 | A1600 SS+1d | 0d |  | Ingeniero Residente de Obra [1416 h]; Ing. SSOMA [1416 h]; Operario [1416 h]; Bombas de funigación [1416 h]; Bioestimulantes Foliales [1416 lt] | 125,213.34 |
|  | 5 | **Aplicación de Micorrizas** |  | 2025-06-03 | 2026-01-12 |  |  |  |  |  |
| A2600 |  | Apliación de Micorrizas | 224d | 2025-06-03 | 2026-01-12 | A1600 SS+1d | 0d |  | Ingeniero Residente de Obra [240 h]; Ing. SSOMA [240 h]; Operario [240 h]; Herramientas Manuales [240 h]; Emienda Micorriza [240 kg] | 2,742.6 |
|  | 6 | **Monitoreo de Plantaciones** |  | 2025-06-03 | 2026-01-12 |  |  |  |  |  |
| A2610 |  | Monitoreo de Plantaciones | 224d | 2025-06-03 | 2026-01-12 | A1600 SS+1d | 0d |  | Ingeniero Residente de Obra [2112 h]; Ing. SSOMA [2112 h]; Operario [2112 h] | 7,238.88 |
|  | 4 | **Infraestructura Verde y Paisajismo - Paquete 03** |  | 2024-08-08 | 2026-01-12 |  |  |  |  |  |
|  | 1 | **Revegetación / Reforestación De La Ribera** |  | 2024-08-08 | 2026-01-12 |  |  |  |  |  |
|  | 1 | **Preparación Del Terreno** |  | 2024-08-08 | 2026-01-12 |  |  |  |  |  |
| A1610 |  | Ubicación Y Delimitación De La Zona De Trabajo | 5d | 2024-08-08 | 2024-08-12 | A0900 | 422d | 0d | Ingeniero Residente de Obra [40 h]; Ing. SSOMA [40 h]; Operario [40 h]; Peón [40 h]; Concreto Ciclopeo [40 m3]; Parantes de Madsera de 1 1/2 x 1 1/2" [40 Unid]; Cinta de Señalización de Peligro [40 Unid] | 2,662.65 |
| A1620 |  | Trazado, Marcación Y Estacado | 5d | 2024-08-13 | 2024-08-17 | A1610 | 422d | 0d | Ingeniero Residente de Obra [40 h]; Ing. SSOMA [40 h]; Jefe de Topografia [40 h]; Nivel Topografico [40 h]; Operario [40 h]; Peón [40 h]; Yeso [40 kg]; Estacas de Madera [40 Unid]; Cordel [40 m]; Estación Total [40 h]; Herramientas Manuales [40 h] | 1,902.65 |
| A1630 |  | Limpieza Y Desbroce Del Terreno Con Medios Manuales | 5d | 2024-08-18 | 2024-08-22 | A1620 | 422d | 0d | Ingeniero Residente de Obra [40 h]; Ing. SSOMA [40 h]; Operario [40 h]; Peón [40 h]; Herramientas Manuales [40 h] | 234.65 |
| A1640 |  | Eliminación De Materiales De Desbroce (Incluye Transporte) | 1d | 2024-08-23 | 2024-08-23 | A1630 | 422d | 0d | Herramientas Manuales [24 h]; Ingeniero Residente de Obra [24 h]; Ing. SSOMA [24 h]; Operario [24 h]; Peón [24 h]; Retroexcavadora Case 590 SK [24 h]; Camión Volquete de 15 m3 [24 h] | 8,432.79 |
| A1650 |  | Despedregado Del Terreno Con Medios Manuales | 5d | 2024-08-24 | 2024-08-28 | A1640 | 422d | 0d | Ingeniero Residente de Obra [64 h]; Ing. SSOMA [64 h]; Peón [64 h]; Herramientas Manuales [64 h] | 156.08 |
| A1680 |  | Preparación Y Aporte Del Sustrato | 20d | 2024-10-28 | 2024-11-16 | A1650 FS+60d | 422d |  | Ingeniero Residente de Obra [480 h]; Ing. SSOMA [480 h]; Sustrato [480 m3]; Herramientas Manuales [480 h]; Zaranda [480 h] | 31,060.8 |
| A1690 |  | Riego De Áreas Vegetadas Con Camión Cisterna | 414d | 2024-11-25 | 2026-01-12 | A1700 FS+1d | 0d |  | Ingeniero Residente de Obra [720 h]; Ing. SSOMA [720 h]; Operario [720 h]; Camión Cisterna (2,500 GLNS.) [720 h] | 117,667.8 |

| ID | WBS | Activity | Duration | Start | Finish | Predecessors | Total float | Free float | Resources | Cost |
| --- | --- | --- | --- | --- | --- | --- | --- | --- | --- | --- |
|  | 2 | **Especies Arbustivas** |  | 2024-11-04 | 2024-12-23 |  |  |  |  |  |
| A1700 |  | Tessaria Integrifolia (Pájaro Bobo) Incluye Siembra Y Transporte | 20d | 2024-11-04 | 2024-11-23 | A1500 FS+60d | 0d |  | Ingeniero Residente de Obra [80 h]; Ing. SSOMA [80 h]; Ing. Responsable de Calidad [80 h]; Operario [80 h]; Peón [80 h]; Tessaria Integrifolia (Pajaro Bobo) [80 Unid]; Herramientas Manuales [80 h] | 1,669.3 |
| A1710 |  | Baccharis Latifolia (Chilco) Incluye Siembra Y Transporte | 20d | 2024-12-04 | 2024-12-23 | A1500 FS+90d | 385d |  | Herramientas Manuales [80 h]; Ingeniero Residente de Obra [80 h]; Ing. SSOMA [80 h]; Ing. Responsable de Calidad [80 h]; Operario [80 h]; Peón [80 h]; Baccharis Latifolia (Chilco) [80 Unid] | 1,669.3 |
|  | 3 | **Especies Arbóreas** |  | 2025-06-02 | 2025-09-24 |  |  |  |  |  |
| A1740 |  | Salix Humboldtiana (Sauce) Incluye Siembra Y Transporte | 20d | 2025-06-02 | 2025-06-21 | A1500 FS+270d | 28d | 0d | Ingeniero Residente de Obra [40 h]; Ing. SSOMA [40 h]; Ing. Responsable de Calidad [40 h]; Operario [40 h]; Peón [40 h]; Salix Humboldtina (Sauce) [40 Unid]; Herramientas Manuales [40 h] | 1,434.65 |
| A1720 |  | Schinus Molle (Molle) Incluye Siembra Y Transporte | 20d | 2025-09-05 | 2025-09-24 | A1500 FS+365d | 110d |  | Ingeniero Residente de Obra [160 h]; Ing. SSOMA [160 h]; Ing. Responsable de Calidad [160 h]; Operario [160 h]; Peón [160 h]; Schinus Molle (Molle) [160 Unid]; Herramientas Manuales [160 h] | 4,538.6 |
| A1730 |  | Acacia Macracantha (Huarango) Incluye Siembra Y Transporte | 20d | 2025-09-05 | 2025-09-24 | A1500 FS+365d | 110d |  | Herramientas Manuales [160 h]; Ingeniero Residente de Obra [160 h]; Ing. SSOMA [160 h]; Ing. Responsable de Calidad [160 h]; Operario [160 h]; Peón [160 h]; Acacia Macracantha (Huarango) [160 Unid] | 4,538.6 |
|  | 4 | **Mantenimiento Post Plantación** |  | 2025-06-03 | 2025-12-15 |  |  |  |  |  |
|  | 1 | **Mantenimiento de Vegetación Arborea** |  | 2025-06-03 | 2025-12-15 |  |  |  |  |  |
| A2620 |  | Deshierbe | 196d | 2025-06-03 | 2025-12-15 | A1740 SS+1d | 28d |  | Herramientas Manuales [1568 h]; Ingeniero Residente de Obra [1568 h]; Ing. SSOMA [1568 h]; Operario [1568 h] | 5,374.32 |
| A2630 |  | Control de Plagas | 117d | 2025-06-03 | 2025-09-27 | A1740 SS+1d | 107d |  | Bombas de funigación [936 h]; Ingeniero Residente de Obra [936 h]; Ing. SSOMA [936 h]; Operario [936 h]; Insecticidas [936 lt] | 143,608.14 |
| A2640 |  | Poda | 117d | 2025-06-03 | 2025-09-27 | A1740 SS+1d | 107d |  | Herramientas Manuales [936 h]; Ingeniero Residente de Obra [936 h]; Ing. SSOMA [936 h]; Operario [936 h] | 3,208.14 |
| A2650 |  | Recalce | 117d | 2025-06-03 | 2025-09-27 | A1740 SS+1d | 107d |  | Ingeniero Residente de Obra [936 h]; Ing. SSOMA [936 h]; Operario [936 h]; Herramientas Manuales [936 h] | 3,208.14 |
|  | 2 | **Mantenimiento de Vegetación Arbustiva** |  | 2025-06-03 | 2025-07-21 |  |  |  |  |  |
| A2660 |  | Deshierva | 49d | 2025-06-03 | 2025-07-21 | A1740 SS+1d | 175d |  | Ingeniero Residente de Obra [392 h]; Ing. SSOMA [392 h]; Operario [392 h]; Herramientas Manuales [392 h] | 1,343.58 |
| A2670 |  | Recalce | 49d | 2025-06-03 | 2025-07-21 | A1740 SS+1d | 175d |  | Herramientas Manuales [392 h]; Ingeniero Residente de Obra [392 h]; Ing. SSOMA [392 h]; Operario [392 h] | 1,343.58 |
|  | 3 | **Bioestimulación** |  | 2025-06-03 | 2025-07-21 |  |  |  |  |  |
| A2680 |  | Aplicación de Enraizante | 49d | 2025-06-03 | 2025-07-21 | A1740 SS+1d | 175d |  | Erraizante Liquido [392 lt]; Ingeniero Residente de Obra [392 h]; Ing. SSOMA [392 h]; Operario [392 h]; Bombas de funigación [392 h] | 34,663.58 |
|  | 4 | **Fertilización Quimica** |  | 2025-06-03 | 2025-07-21 |  |  |  |  |  |
| A2690 |  | Fertilización de liberación lenta NPK | 49d | 2025-06-03 | 2025-07-21 | A1740 SS+1d | 175d |  | Ingeniero Residente de Obra [392 h]; Ing. SSOMA [392 h]; Operario [392 h]; Fertilizante NPK liberación lenta [392 kg]; Herramientas Manuales [392 h] | 1,177,343.58 |
| A2700 |  | Aplicación Foliar bioestimulantes | 49d | 2025-06-03 | 2025-07-21 | A1740 SS+1d | 175d |  | Ingeniero Residente de Obra [392 h]; Ing. SSOMA [392 h]; Operario [392 h]; Bioestimulantes Foliales [392 lt]; Bombas de funigación [392 h] | 34,663.58 |
|  | 5 | **Aplicación de Micorrizas** |  | 2025-06-03 | 2025-07-02 |  |  |  |  |  |
| A2710 |  | Aplicación de Micorrizas | 30d | 2025-06-03 | 2025-07-02 | A1740 SS+1d | 194d |  | Ingeniero Residente de Obra [240 h]; Ing. SSOMA [240 h]; Operario [240 h]; Emienda Micorriza [240 kg]; Herramientas Manuales [240 h] | 2,742.6 |
|  | 6 | **Monitoreo de Plantaciones** |  | 2025-06-03 | 2025-12-15 |  |  |  |  |  |
| A2720 |  | Monitoreo de Plantaciones | 196d | 2025-06-03 | 2025-12-15 | A1740 SS+1d | 28d |  | Ingeniero Residente de Obra [1568 h]; Ing. SSOMA [1568 h]; Operario [1568 h] | 5,374.32 |

| ID | WBS | Activity | Duration | Start | Finish | Predecessors | Total float | Free float | Resources | Cost |
| --- | --- | --- | --- | --- | --- | --- | --- | --- | --- | --- |
|  | 5 | **Infraestructura Verde y Paisajismo - Paquete 04** |  | 2024-08-08 | 2026-01-12 |  |  |  |  |  |
|  | 1 | **Revegetación / Reforestación De La Ribera** |  | 2024-08-08 | 2026-01-12 |  |  |  |  |  |
|  | 1 | **Preparación Del Terreno** |  | 2024-08-08 | 2026-01-12 |  |  |  |  |  |
| A1750 |  | Ubicación Y Delimitación De La Zona De Trabajo | 5d | 2024-08-08 | 2024-08-12 | A0900 | 0d |  | Ingeniero Residente de Obra [40 h]; Ing. SSOMA [40 h]; Operario [40 h]; Peón [40 h]; Concreto Ciclopeo [40 m3]; Parantes de Madsera de 1 1/2 x 1 1/2" [40 Unid]; Cinta de Señalización de Peligro [40 Unid] | 2,662.65 |
| A1760 |  | Trazado, Marcación Y Estacado | 5d | 2024-08-13 | 2024-08-17 | A1750 | 0d |  | Ingeniero Residente de Obra [40 h]; Ing. SSOMA [40 h]; Ing. Responsable de Calidad [40 h]; Jefe de Topografia [40 h]; Operario [40 h]; Peón [40 h]; Yeso [40 kg]; Estacas de Madera [40 Unid]; Cordel [40 m]; Estación Total [40 h]; Nivel Topografico [40 h]; Herramientas Manuales [40 h] | 1,902.65 |
| A1770 |  | Limpieza Y Desbroce Del Terreno Con Medios Manuales | 5d | 2024-08-18 | 2024-08-22 | A1760 | 0d |  | Herramientas Manuales [40 h]; Ingeniero Residente de Obra [40 h]; Ing. SSOMA [40 h]; Operario [40 h]; Peón [40 h]; Herramientas Manuales | 234.65 |
| A1780 |  | Eliminación De Materiales De Desbroce (Incluye Transporte) | 1d | 2024-08-23 | 2024-08-23 | A1770 | 0d |  | Herramientas Manuales [24 h]; Ingeniero Residente de Obra [24 h]; Ing. SSOMA [24 h]; Operario [24 h]; Peón [24 h]; Retroexcavadora Case 590 SK [24 h]; Camión Volquete de 15 m3 [24 h] | 8,432.79 |
| A1790 |  | Despedregado Del Terreno Con Medios Manuales | 5d | 2024-08-24 | 2024-08-28 | A1780 | 0d |  | Ingeniero Residente de Obra [40 h]; Ing. SSOMA [40 h]; Peón [40 h]; Herramientas Manuales [40 h] | 97.55 |
| A1820 |  | Tala De Árbol Con Medio Mecánico | 5d | 2024-09-05 | 2024-09-09 | A1500 | 483d | 0d | Ingeniero Residente de Obra [24 h]; Ing. SSOMA [24 h]; Operario [24 h]; Peón [24 h]; Herramientas Manuales [24 h]; Motosierra [24 h] | 481.59 |
| A1830 |  | Especies Arbóreas A Compensar | 7d | 2024-09-10 | 2024-09-16 | A1820 | 483d |  | Ingeniero Residente de Obra [56 h]; Ing. SSOMA [56 h]; Ing. Responsable de Calidad [56 h]; Operario [56 h]; Peón [56 h]; Especies Arbóreas [56 Unid]; Herramientas Manuales [56 h] | 1,448.51 |
| A1800 |  | Preparación Y Aporte Del Sustrato | 20d | 2024-11-04 | 2024-11-23 | A1500 FS+60d | 415d |  | Ingeniero Residente de Obra [520 h]; Ing. SSOMA [520 h]; Ing. Responsable de Calidad [520 h]; Operario [520 h]; Peón [520 h]; Sustrato [520 m3]; Herramientas Manuales [520 h]; Zaranda [520 h] | 36,699.65 |
| A1810 |  | Riego De Áreas Vegetadas Con Camión Cisterna | 204d | 2025-06-23 | 2026-01-12 | A1860 FS+1d | 0d |  | Ingeniero Residente de Obra [720 h]; Ing. SSOMA [720 h]; Operario [720 h]; Camión Cisterna (2,500 GLNS.) [720 h] | 117,667.8 |
|  | 2 | **Especies Arbóreas** |  | 2025-06-02 | 2025-09-24 |  |  |  |  |  |
| A1860 |  | Salix Humboldtiana (Sauce) Incluye Siembra Y Transporte | 20d | 2025-06-02 | 2025-06-21 | A1500 FS+270d | 0d |  | Ingeniero Residente de Obra [40 h]; Ing. SSOMA [40 h]; Ing. Responsable de Calidad [40 h]; Operario [40 h]; Peón [40 h]; Salix Humboldtina (Sauce) [40 Unid]; Herramientas Manuales [40 h] | 1,434.65 |
| A1840 |  | Schinus Molle (Molle) Incluye Siembra Y Transporte | 20d | 2025-09-05 | 2025-09-24 | A1500 FS+365d | 110d |  | Herramientas Manuales [80 h]; Ingeniero Residente de Obra [80 h]; Ing. SSOMA [80 h]; Ing. Responsable de Calidad [80 h]; Operario [80 h]; Peón [80 h]; Schinus Molle (Molle) [80 Unid] | 2,269.3 |
| A1850 |  | Acacia Macracantha (Huarango) Incluye Siembra Y Transporte | 20d | 2025-09-05 | 2025-09-24 | A1500 FS+365d | 110d |  | Ingeniero Residente de Obra [80 h]; Ing. SSOMA [80 h]; Ing. Responsable de Calidad [80 h]; Operario [80 h]; Peón [80 h]; Herramientas Manuales [80 h]; Acacia Macracantha (Huarango) [80 Unid] | 2,269.3 |
|  | 3 | **Espacio Público Próximo A Bocatoma Fortaleza** |  | 2024-08-23 | 2026-01-12 |  |  |  |  |  |
|  | 1 | **Preparación Del Terreno** |  | 2024-08-23 | 2026-01-12 |  |  |  |  |  |
| A1870 |  | Ubicación Y Delimitación De La Zona De Trabajo | 5d | 2024-08-23 | 2024-08-27 | A1750 SS+15d | 500d | 0d | Ingeniero Residente de Obra [40 h]; Ing. SSOMA [40 h]; Operario [40 h]; Peón [40 h]; Concreto Ciclopeo [40 m3]; Parantes de Madsera de 1 1/2 x 1 1/2" [40 Unid]; Cinta de Señalización de Peligro [40 Unid] | 2,662.65 |
| A1880 |  | Trazado, Marcación Y Estacado | 5d | 2024-08-23 | 2024-08-27 | A1870 SS | 503d |  | Ingeniero Residente de Obra [40 h]; Ing. SSOMA [40 h]; Jefe de Topografia [40 h]; Operario [40 h]; Peón [40 h]; Yeso [40 kg]; Estacas de Madera [40 Unid]; Cordel [40 m]; Estación Total [40 h]; Nivel Topografico [40 h]; Herramientas Manuales [40 h] | 1,902.65 |
| A1890 |  | Limpieza Y Desbroce Del Terreno Con Medios Manuales | 5d | 2024-08-23 | 2024-08-27 | A1870 SS | 500d | 0d | Herramientas Manuales [40 h]; Ingeniero Residente de Obra [40 h]; Ing. SSOMA [40 h]; Operario [40 h]; Peón [40 h] | 234.65 |
| A1910 |  | Remoción Del Terreno Con Medios Manuales Con Profundidad Hasta 25 Cm | 3d | 2024-08-27 | 2024-08-29 | A1900 FF | 500d | 0d | Ingeniero Residente de Obra [24 h]; Ing. SSOMA [24 h]; Operario [24 h]; Peón [24 h]; Herramientas Manuales [24 h] | 140.79 |
| A1900 |  | Eliminación De Materiales De Desbroce (Incluye Transporte) | 2d | 2024-08-28 | 2024-08-29 | A1890 | 500d | 0d | Ingeniero Residente de Obra [16 h]; Ing. SSOMA [16 h]; Operario [16 h]; Peón [16 h]; Herramientas Manuales [16 h]; Retroexcavadora Case 590 SK [16 h]; Camión Volquete de 15 m3 [16 h] | 5,621.86 |
| A1920 |  | Rastrillado Del Terreno | 3d | 2024-08-28 | 2024-08-30 | A1910 SS+1d | 500d |  | Herramientas Manuales [24 h]; Ingeniero Residente de Obra [24 h]; Ing. SSOMA [24 h]; Peón [24 h] | 58.53 |
| A1930 |  | Preparación Y Aporte Del Sustrato | 15d | 2024-11-04 | 2024-11-18 | A1500 FS+60d | 420d |  | Ingeniero Residente de Obra [160 h]; Ing. SSOMA [160 h]; Ing. Responsable de Calidad [160 h]; Operario [160 h]; Peón [160 h]; Sustrato [160 m3]; Herramientas Manuales [160 h]; Zaranda [160 h] | 11,292.2 |
| A1940 |  | Riego De Áreas Vegetadas Con Camión Cisterna | 419d | 2024-11-20 | 2026-01-12 | A1990 FS+1d | 0d |  | Ingeniero Residente de Obra [720 h]; Ing. SSOMA [720 h]; Operario [720 h]; Peón [720 h]; Camión Cisterna (2,500 GLNS.) [720 h] | 119,423.7 |

| ID | WBS | Activity | Duration | Start | Finish | Predecessors | Total float | Free float | Resources | Cost |
| --- | --- | --- | --- | --- | --- | --- | --- | --- | --- | --- |
|  | 2 | **Especies Arbustivas** |  | 2025-05-03 | 2025-09-24 |  |  |  |  |  |
| A1950 |  | Galvezia Fruticosa (Galvezia). Incluye Siembra Y Transporte | 20d | 2025-05-03 | 2025-05-22 | A1500 FS+240d | 19d | 0d | Ingeniero Residente de Obra [16 h]; Ing. SSOMA [16 h]; Ing. Responsable de Calidad [16 h]; Operario [16 h]; Peón [16 h]; Galvezia Fruticosa (Galvezia) [16 Unid]; Herramientas Manuales [16 h] | 333.86 |
| A1960 |  | Bougainvillea Peruviana (Buganvilla). Incluye Siembra Y Transporte | 20d | 2025-09-05 | 2025-09-24 | A1500 FS+365d | 110d |  | Herramientas Manuales [16 h]; Peón [16 h]; Operario [16 h]; Bougainvellea Peruviana (Buganvilla) [16 Unid]; Ingeniero Residente de Obra [16 h]; Ing. SSOMA [16 h]; Ing. Responsable de Calidad [16 h] | 333.86 |
|  | 3 | **Especies Arbóreas** |  | 2025-09-05 | 2025-09-24 |  |  |  |  |  |
| A1970 |  | Schinus Molle (Molle) Incluye Siembra Y Transporte | 20d | 2025-09-05 | 2025-09-24 | A1500 FS+365d | 110d |  | Ing. Responsable de Calidad [8 h]; Ingeniero Residente de Obra [8 h]; Ing. SSOMA [8 h]; Operario [8 h]; Peón [8 h]; Schinus Molle (Molle) [8 Unid]; Herramientas Manuales [8 h] | 226.93 |
| A1980 |  | Acacia Macracantha (Huarango) Incluye Siembra Y Transporte | 20d | 2025-09-05 | 2025-09-24 | A1500 FS+365d | 110d |  | Herramientas Manuales [8 h]; Operario [8 h]; Peón [8 h]; Acacia Macracantha (Huarango) [8 Unid]; Ingeniero Residente de Obra [8 h]; Ing. SSOMA [8 h]; Ing. Responsable de Calidad [8 h] | 226.93 |
|  | 4 | **Especies Cubresuelos** |  | 2024-11-04 | 2024-11-18 |  |  |  |  |  |
| A1990 |  | Lippia Nodiflora (Bella Alfombra). Incluye Siembra Y Transporte | 15d | 2024-11-04 | 2024-11-18 | A1500 FS+60d | 0d |  | Ingeniero Residente de Obra [56 h]; Ing. SSOMA [56 h]; Ing. Responsable de Calidad [56 h]; Operario [56 h]; Peón [56 h]; Lippia Nodiflora (Bella Alfombra) [56 m2]; Herramientas Manuales [56 h] | 328.51 |
|  | 5 | **Formación De Senderos Y Plataformas** |  | 2024-11-19 | 2024-12-05 |  |  |  |  |  |
| A2000 |  | Conformación Y Compactación De Base Granular De Espesor E=0.15m (Incluye Material) | 5d | 2024-11-19 | 2024-11-23 | A1990 | 386d | 0d | Ingeniero Residente de Obra [40 h]; Ing. SSOMA [40 h]; Ing. Responsable de Calidad [40 h]; Operario [40 h]; Peón [40 h]; Material Granular [40 m3]; Agua Puesta en Obra [40 m3]; Herramientas Manuales [40 h]; Compactadora Vibratoria Tipo Plancha 7 HP [40 h] | 4,492.25 |
| A2010 |  | Capa Superficial De Arena De Espesor E=0.05m | 5d | 2024-11-24 | 2024-11-28 | A2000 | 386d | 0d | Ingeniero Residente de Obra [40 h]; Ing. SSOMA [40 h]; Ing. Responsable de Calidad [40 h]; Operario [40 h]; Peón [40 h]; Arena [40 m3]; Agua Puesta en Obra [40 m3]; Herramientas Manuales [40 h] | 3,514.65 |
| A2020 |  | Borde De Troncos De Madera De Altura 15 Cm Sobre El Nivel De Piso Y Altura Total 50 Cm Diámetro 4" | 7d | 2024-11-29 | 2024-12-05 | A2010 | 386d | 0d | Ingeniero Residente de Obra [56 h]; Ing. SSOMA [56 h]; Ing. Responsable de Calidad [56 h]; Operario [56 h]; Peón [56 h]; Tronco de Madera [56 Unid]; Herramientas Manuales [56 h] | 776.51 |
|  | 6 | **Elementos Arquitectónicos** |  | 2024-12-06 | 2024-12-10 |  |  |  |  |  |
| A2030 |  | Baranda Rústica De Madera De Huayruro De Altura H=1.00 M En Terreno Natural | 5d | 2024-12-06 | 2024-12-10 | A2020 | 386d | 0d | Ingeniero Residente de Obra [40 h]; Ing. SSOMA [40 h]; Ing. Responsable de Calidad [40 h]; Operario [40 h]; Peón [40 h]; Clavos para Madera con Cabeza de 2 1/2" [40 kg]; Madera Huayruro [40 P2]; Insecticida Antitermitas [40 gal]; Herramientas Manuales [40 h] | 3,854.65 |
|  | 7 | **Mobiliario Urbano** |  | 2024-12-11 | 2024-12-16 |  |  |  |  |  |
| A2040 |  | Banca De Madera Sobre Gavión. Tipo T2 | 3d | 2024-12-11 | 2024-12-13 | A2030 | 386d | 0d | Ingeniero Residente de Obra [24 h]; Ing. SSOMA [24 h]; Ing. Responsable de Calidad [24 h]; Operario [24 h]; Peón [24 h]; Clavos para Madera con Cabeza de 2 1/2" [24 kg]; Plancha de Acero 8mm [24 kg]; Madera Tornillo [24 P2]; Insecticida Antitermitas [24 gal] | 2,588.79 |
| A2050 |  | Papeleras De Reciclaje De Acabado De Madera En Estructura De 4 (75 Litros C/U) | 1d | 2024-12-14 | 2024-12-14 | A2040 | 386d | 0d | Ingeniero Residente de Obra [8 h]; Ing. SSOMA [8 h]; Ing. Responsable de Calidad [8 h]; Operario [8 h]; Peón [8 h]; Herramientas Manuales [8 h]; Papelera de Reciclaje [8 Unid] | 9,646.93 |
| A2060 |  | Piedra Ornamental Para Espacio Público | 2d | 2024-12-15 | 2024-12-16 | A2050 | 386d | 0d | Ingeniero Residente de Obra [16 h]; Ing. SSOMA [16 h]; Ing. Responsable de Calidad [16 h]; Operario [16 h]; Peón [16 h]; Herramientas Manuales [16 h] | 93.86 |
|  | 8 | **Señalética Informativa** |  | 2024-12-17 | 2024-12-18 |  |  |  |  |  |
| A2070 |  | Panel Informativo H=1.25m. Tipo A | 1d | 2024-12-17 | 2024-12-17 | A2060 | 390d | 0d | Herramientas Manuales [8 h]; Ingeniero Residente de Obra [8 h]; Ing. SSOMA [8 h]; Operario [8 h]; Peón [8 h]; Clavos para Madera con Cabeza de 2 1/2" [8 kg]; Hormigon [8 m3]; Agua Puesta en Obra [8 m3]; Banner Señalitica Digital [8 Unid]; Cemento Porland Tipo I (42.5 kg) [8 bol]; Madera Tornillo [8 P2] | 1,601.33 |
| A2080 |  | Panel Informativo H=2.10m. Tipo B | 1d | 2024-12-18 | 2024-12-18 | A2070 | 390d |  | Ingeniero Residente de Obra [8 h]; Ing. SSOMA [8 h]; Operario [8 h]; Peón [8 h]; Clavos para Madera con Cabeza de 2 1/2" [8 kg]; Hormigon [8 m3]; Agua Puesta en Obra [8 m3]; Banner Señalitica Digital [8 Unid]; Cemento Porland Tipo I (42.5 kg) [8 bol]; Madera Tornillo [8 P2]; Herramientas Manuales [8 h] | 1,601.33 |
|  | 9 | **Obras De Concreto Armado** |  | 2024-12-17 | 2024-12-22 |  |  |  |  |  |
| A2090 |  | Excavación En Material Suelto, Con Equipo | 1d | 2024-12-17 | 2024-12-17 | A2060 | 386d | 0d | Ingeniero Residente de Obra [8 h]; Ing. SSOMA [8 h]; Peón [8 h]; Retroexcavadora Case 590 SK [8 h] | 1,503.51 |
| A2100 |  | Conformación De Dme/Dmo | 1d | 2024-12-18 | 2024-12-18 | A2090 | 386d | 0d | Ingeniero Residente de Obra [8 h]; Ing. SSOMA [8 h]; Ing. Responsable de Calidad [8 h]; Operario [8 h]; Peón [8 h]; Agua Puesta en Obra [8 m3]; Herramientas Manuales [8 h]; Compactadora Vibratoria Tipo Plancha 7 HP [8 h] | 454.45 |
| A2120 |  | Acero En Barras Corrugadas (Fy=420mpa) | 1d | 2024-12-19 | 2024-12-19 | A2130 SS | 389d |  | Ingeniero Residente de Obra [8 h]; Ing. SSOMA [8 h]; Operario [8 h]; Peón [8 h]; Alambre Negro Recocido N° 16 [8 kg]; Acero Corrugado fy= 4200 kg/cm2 Grado 60 [8 kg]; Herramientas Manuales [8 h] | 113.65 |
| A2130 |  | Encofrado Y Desencofrado | 1d | 2024-12-19 | 2024-12-19 | A2100 | 386d | 0d | Herramientas Manuales [8 h]; Ingeniero Residente de Obra [8 h]; Ing. SSOMA [8 h]; Operario [8 h]; Peón [8 h]; Alambre Negro Recocido N° 08 [8 kg]; Clavos para Madera con Cabeza de 2 1/2" [8 kg]; Madera Tornillo [8 P2] | 184.21 |
| A2110 |  | Concreto (F'c = 21 Mpa) En Cimentación | 1d | 2024-12-20 | 2024-12-20 | A2130 | 386d | 0d | Ingeniero Residente de Obra [8 h]; Ing. SSOMA [8 h]; Ing. Responsable de Calidad [8 h]; Operario [8 h]; Peón [8 h]; Piedra Chancada 1/2" [8 m3]; Arena Gruesa [8 m3]; Agua Puesta en Obra [8 m3]; Cemento Porland Tipo I (42.5 kg) [8 bol]; Herramientas Manuales [8 h]; Vibrador de Concreto 4 HP 1.25" [8 h]; Mezcladora de Concreto 11 P3 (23 HP) [8 h] | 1,668.13 |
| A2170 |  | Perno De Anclaje Ø1/4" Expansivo A307 L=114mm | 1d | 2024-12-20 | 2024-12-20 | A2110 SS | 388d |  | Ingeniero Residente de Obra [8 h]; Ing. SSOMA [8 h]; Operario [8 h]; Peón [8 h]; Perno de Anclaje de 1/4" Expansivo A307 L=114 mm [8 Unid]; Herramientas Manuales [8 h] | 146.93 |
| A2140 |  | Acero Estructural A36 | 1d | 2024-12-21 | 2024-12-21 | A2110 | 387d |  | Ingeniero Residente de Obra [8 h]; Ing. SSOMA [8 h]; Operario [8 h]; Peón [8 h]; Acero Estructural A36 [8 kg]; Herramientas Manuales [8 h] | 154.93 |
| A2180 |  | Tubo Astm A500/A500m | 1d | 2024-12-21 | 2024-12-21 | A2110 | 386d | 0d | Ingeniero Residente de Obra [8 h]; Ing. SSOMA [8 h]; Operario [8 h]; Peón [8 h]; Tubo ASTM A500/A500M [8 m]; Herramientas Manuales [8 h] | 162.93 |
| A2150 |  | Tornillo Galvanizado Ø1/4" Pasante A307 (Incluido Con Tuerca Y Arandela Plana) | 1d | 2024-12-22 | 2024-12-22 | A2180 | 386d | 0d | Herramientas Manuales [8 h]; Ingeniero Residente de Obra [8 h]; Ing. SSOMA [8 h]; Operario [8 h]; Peón [8 h]; Tornillo Galvanizado D=1/4" Pasante A307 [8 Unid]; Arandela Plana de 1/4" [8 Unid]; Tuerca 1/4" [8 Unid] | 152.53 |
| A2160 |  | Perno De Anclaje Ø1/4" Expansivo A307 L=57mm | 1d | 2024-12-22 | 2024-12-22 | A2150 SS | 386d |  | Ingeniero Residente de Obra [8 h]; Ing. SSOMA [8 h]; Operario [8 h]; Peón [8 h]; Perno de Anclaje de 1/4" Expansivo A307 L=57 mm [8 Unid]; Herramientas Manuales [8 h] | 106.93 |

| ID | WBS | Activity | Duration | Start | Finish | Predecessors | Total float | Resources | Cost |
| --- | --- | --- | --- | --- | --- | --- | --- | --- | --- |
|  | 10 | **Mantenimiento Post Plantación** |  | 2025-05-04 | 2025-12-24 |  |  |  |  |
|  | 1 | **Mantenimiento de Vegetación Arborea** |  | 2025-05-04 | 2025-12-24 |  |  |  |  |
| A2730 |  | Deshierve | 235d | 2025-05-04 | 2025-12-24 | A1950 SS+1d | 19d | Ingeniero Residente de Obra [960 h]; Ing. SSOMA [960 h]; Operario [960 h]; Herramientas Manuales [960 h] | 3,290.4 |
| A2740 |  | Control de Plagas | 120d | 2025-05-04 | 2025-08-31 | A1950 SS+1d | 134d | Insecticidas [960 lt]; Ingeniero Residente de Obra [960 h]; Ing. SSOMA [960 h]; Operario [960 h]; Bombas de funigación [960 h] | 147,290.4 |
| A2750 |  | Poda | 120d | 2025-05-04 | 2025-08-31 | A1950 SS+1d | 134d | Herramientas Manuales [960 h]; Ingeniero Residente de Obra [960 h]; Ing. SSOMA [960 h]; Operario [960 h] | 3,290.4 |
| A2760 |  | Recalce | 120d | 2025-05-04 | 2025-08-31 | A1950 SS+1d | 134d | Ingeniero Residente de Obra [960 h]; Ing. SSOMA [960 h]; Operario [960 h]; Herramientas Manuales [960 h] | 3,290.4 |
|  | 2 | **Mantenimiento de Vegetación Arbustiva** |  | 2025-05-04 | 2025-08-31 |  |  |  |  |
| A2770 |  | Deshierva | 120d | 2025-05-04 | 2025-08-31 | A1950 SS+1d | 134d | Herramientas Manuales [960 h]; Ingeniero Residente de Obra [960 h]; Ing. SSOMA [960 h]; Operario [960 h] | 3,290.4 |
| A2780 |  | Recalce | 120d | 2025-05-04 | 2025-08-31 | A1950 SS+1d | 134d | Ingeniero Residente de Obra [960 h]; Ing. SSOMA [960 h]; Operario [960 h]; Herramientas Manuales [960 h] | 3,290.4 |
|  | 3 | **Bioestimulación** |  | 2025-05-04 | 2025-08-31 |  |  |  |  |
| A2790 |  | Aplicación de Enraizante | 120d | 2025-05-04 | 2025-08-31 | A1950 SS+1d | 134d | Bombas de funigación [960 h]; Ingeniero Residente de Obra [960 h]; Ing. SSOMA [960 h]; Operario [960 h]; Erraizante Liquido [960 lt] | 84,890.4 |
|  | 4 | **Fertilización Quimica** |  | 2025-05-04 | 2025-08-31 |  |  |  |  |
| A2800 |  | Fertilización de liberación lenta NPK | 120d | 2025-05-04 | 2025-08-31 | A1950 SS+1d | 134d | Ingeniero Residente de Obra [960 h]; Ing. SSOMA [960 h]; Operario [960 h]; Herramientas Manuales [960 h]; Fertilizante NPK liberación lenta [960 kg] | 2,883,290.4 |
| A2810 |  | Aplicación Foliar Bioestimulantes | 120d | 2025-05-04 | 2025-08-31 | A1950 SS+1d | 134d | Ingeniero Residente de Obra [960 h]; Ing. SSOMA [960 h]; Operario [960 h]; Bombas de funigación [960 h]; Bioestimulantes Foliales [960 lt] | 84,890.4 |
|  | 5 | **Aplicación de Micorrizas** |  | 2025-05-04 | 2025-08-31 |  |  |  |  |
| A2820 |  | Aplicación de Microrrizas | 120d | 2025-05-04 | 2025-08-31 | A1950 SS+1d | 134d | Ingeniero Residente de Obra [960 h]; Ing. SSOMA [960 h]; Operario [960 h]; Herramientas Manuales [960 h]; Emienda Micorriza [960 kg] | 10,970.4 |
|  | 6 | **Monitoreo de Plantaciones** |  | 2025-05-04 | 2025-08-31 |  |  |  |  |
| A2830 |  | Monitoreo | 120d | 2025-05-04 | 2025-08-31 | A1950 SS+1d | 134d | Ingeniero Residente de Obra [960 h]; Ing. SSOMA [960 h]; Operario [960 h] | 3,290.4 |
